# Proyecto CRM - Corporacion Union

Schedule from MS Project, 2005-11-29 to 2007-01-31.

## Calendars

- Estándar: Mon-Fri 08:00-12:00, 13:00-17:00; Sat-Sun off. Exceptions (off unless hours are given): 2006-02-27 to 2006-02-28, 2006-11-27, 2006-12-25, 2007-01-01.

## Resources

| Resource |
| --- |
| GP |
| DS |
| OP |
| DD |

## Schedule

| ID | WBS | Task | Type | Duration | Start | Finish | Predecessors | Total slack | Constraint | Resources | Work |
| --- | --- | --- | --- | --- | --- | --- | --- | --- | --- | --- | --- |
| 1 | 1 | **Sitio Web Bingo Seven Star** |  | 301.7d | 2005-11-29 | 2007-01-31 |  | 0d |  |  | 276h |
| 2 | 1.1 | **Inicio** |  | 0.25d | 2006-11-28 | 2006-11-28 |  | 29.2d |  |  | 2h |
| 3 | 1.1.1 | Reunión de Arranque (Kickoff) |  | 0.25d | 2006-11-28 | 2006-11-28 |  | 20.2d | start no earlier than 2006-11-28 | GP | 2h |
| 4 | 1.2 | **Especificación de Requerimientos** |  | 4.45d | 2006-11-29 | 2006-12-05 |  | 1d |  |  | 11h |
| 5 | 1.2.1 | **Levantamiento de Información** |  | 1.2d | 2006-11-29 | 2006-11-30 |  | 1d |  |  | 4h |
| 6 | 1.2.1.1 | Sesión de Trabajo Remota # 1 |  | 0.2d | 2006-11-29 | 2006-11-29 |  | 42.25d | start no earlier than 2006-11-29 | GP; DS | 2h |
| 7 | 1.2.1.2 | Sesión de Trabajo Remota # 2 |  | 0.2d | 2006-11-30 | 2006-11-30 |  | 0d | start no earlier than 2006-11-30 | GP; DS | 2h |
| 8 | 1.2.2 | Elaboración del Informe Esp. de Req. y Matriz de Req. |  | 1d | 2006-11-30 | 2006-12-01 | 7 | 0d |  | GP [50%] | 4h |
| 9 | 1.2.3 | Revisión de Informe Esp. por Equipo de Proyecto |  | 0.25d | 2006-12-01 | 2006-12-01 | 8 | 0d |  | DS | 2h |
| 10 | 1.2.4 | Ajustes al Informe Especificación de Requerimientos |  | 1d | 2006-12-01 | 2006-12-04 | 9 | 0d |  | GP [12.5%] | 1h |
| 11 | 1.2.5 | Entrega de Especificación de Requerimientos para aprobación | milestone | 0d | 2006-12-04 | 2006-12-04 | 10 | 0d |  |  |  |
| 12 | 1.2.6 | Revisión por parte del Cliente |  | 1d | 2006-12-04 | 2006-12-05 | 11 | 0d |  |  |  |
| 13 | 1.2.7 | Aprobación del Informe Especificación de Requerimientos | milestone | 0d | 2006-12-05 | 2006-12-05 | 12 | 0d |  |  |  |
| 14 | 1.3 | Informe Especificación de Requerimientos Aprobado | milestone | 0d | 2006-12-05 | 2006-12-05 | 13 | 37.75d |  |  |  |
| 15 | 1.4 | **Configuración y Desarrollo** |  | 279.2d | 2005-11-29 | 2006-12-29 |  | 0d |  |  | 192h |
| 16 | 1.4.1 | **Desarrollo de Nuevas Funcionalidades** |  | 6d | 2006-12-05 | 2006-12-13 |  | 0d |  |  | 64h |
| 17 | 1.4.1.1 | Módulo Directorio de Clientes |  | 2d | 2006-12-05 | 2006-12-07 | 13 | 0d |  | DS | 16h |
| 18 | 1.4.1.2 | Administración Juegos |  | 2d | 2006-12-07 | 2006-12-11 | 17 | 0d |  | DS | 16h |
| 19 | 1.4.1.3 | Módulo Contáctanos |  | 1d | 2006-12-11 | 2006-12-12 | 18 | 0d |  |  | 16h |
| 20 | 1.4.1.4 | Módulo de envio de mensajes (Email y SMS) |  | 1d | 2006-12-12 | 2006-12-13 | 19 | 0d |  |  | 16h |
| 21 | 1.4.2 | **Diseño Gráfico** |  | 3.5d | 2006-12-13 | 2006-12-18 |  | 0d |  |  | 28h |
| 22 | 1.4.2.1 | Propuesta de Diseño |  | 1.5d | 2006-12-13 | 2006-12-14 | 16 | 0d |  | DD | 12h |
| 23 | 1.4.2.2 | Diseño Gráfico |  | 2d | 2006-12-14 | 2006-12-18 | 22 | 0d |  | DD | 16h |
| 24 | 1.4.3 | **Sitio Web** |  | 277.95d | 2005-11-29 | 2006-12-27 |  | 0d |  |  | 80h |
| 25 | 1.4.3.1 | Plantillas |  | 3d | 2005-11-29 | 2005-12-01 |  | 273d |  | DS | 24h |
| 26 | 1.4.3.2 | Módulo de Noticias |  | 4d | 2006-12-18 | 2006-12-22 | 21 | 0d |  | DS | 32h |
| 27 | 1.4.3.3 | Galería de Imágenes |  | 2d | 2006-12-22 | 2006-12-26 | 26 | 0d |  | DS | 16h |
| 28 | 1.4.3.4 | Manejo de Subscripciones |  | 1d | 2006-12-26 | 2006-12-27 | 27 | 0d |  | DS | 8h |
| 29 | 1.4.4 | Pruebas internas y ajustes |  | 1.25d | 2006-12-27 | 2006-12-29 | 24 | 0d |  | DS; GP | 20h |

Notes:
- 5: Se estima un día por sesión de levantamiento de requerimientos. Existen proyectos donde el lev. de información se hace con ejecución de talleres con duración estimada de 2 días hasta una semana. Todo depende. Lo importante es reflejar cada sesión, duración y las fechas pautadas para su ejecución.

| ID | WBS | Task | Type | Duration | Start | Finish | Predecessors | Total slack | Free slack | Resources | Work |
| --- | --- | --- | --- | --- | --- | --- | --- | --- | --- | --- | --- |
| 30 | 1.5 | **Plan de Pruebas** |  | 0.25d | 2006-12-29 | 2006-12-29 |  | 22.25d |  |  | 2h |
| 31 | 1.5.1 | Elaboración Plan de Pruebas |  | 0.12d | 2006-12-29 | 2006-12-29 | 29 | 22.25d | 0d | GP | 1h |
| 32 | 1.5.2 | Revisión Plan de Pruebas con Equipo de Trabajo |  | 0.12d | 2006-12-29 | 2006-12-29 | 31 | 22.25d |  | GP | 1h |
| 33 | 1.6 | **Pruebas de Certificación** |  | 3.5d | 2006-12-29 | 2007-01-04 |  | 0d |  |  | 12h |
| 34 | 1.6.1 | Preparación para las pruebas en ambiente de desarrollo |  | 0.5d | 2006-12-29 | 2006-12-29 | 15 | 0d |  | DS [50%]; GP [50%] | 4h |
| 35 | 1.6.2 | Realización de Pruebas de Funcionalidad |  | 2d | 2006-12-29 | 2007-01-03 | 34 | 0d |  |  |  |
| 36 | 1.6.3 | Realización de Ajustes recomendados |  | 1d | 2007-01-03 | 2007-01-04 | 35 | 0d |  | DS | 8h |
| 37 | 1.6.4 | Pruebas de Certificación aprobada | milestone | 0d | 2007-01-04 | 2007-01-04 | 36 | 0d |  |  |  |
| 38 | 1.7 | Guia de Usuario |  | 15d | 2007-01-04 | 2007-01-25 | 33 | 3.38d | 0d |  |  |
| 39 | 1.8 | **Preparación para el arranque** |  | 21.25d | 2006-12-05 | 2007-01-05 |  | 18d |  |  | 16h |
| 40 | 1.8.1 | **Desarrollo** |  | 1d | 2006-12-05 | 2006-12-06 |  | 38.25d |  |  | 8h |
| 41 | 1.8.1.1 | Configuración Infraestructura Técnica |  | 1d | 2006-12-05 | 2006-12-06 | 13 | 38.25d |  | OP | 8h |
| 42 | 1.8.2 | **Producción** |  | 1d | 2007-01-04 | 2007-01-05 |  | 0d |  |  | 8h |
| 43 | 1.8.2.1 | Configuración Infraestructura Técnica |  | 1d | 2007-01-04 | 2007-01-05 | 37 | 0d |  | OP | 8h |
| 44 | 1.9 | Sitio Web y Funcionalidades en Producción |  | 1d | 2007-01-05 | 2007-01-08 | 42 | 17d |  |  |  |
| 45 | 1.10 | **Puesta en Producción** |  | 18d | 2007-01-05 | 2007-01-31 | 42 | 0d |  |  | 41h |
| 46 | 1.10.1 | Adiestramiento |  | 0.5d | 2007-01-25 | 2007-01-26 | 38 | 3.5d |  | GP | 4h |
| 47 | 1.10.2 | **Gerencia de Proyecto** |  | 18d | 2007-01-05 | 2007-01-31 |  | 0d |  |  | 32h |
| 48 | 1.10.2.1 | Planificación |  | 0.25d | 2007-01-05 | 2007-01-05 | 13 | 17.75d |  | GP | 2h |
| 49 | 1.10.2.2 | Control y Seguimiento |  | 18d | 2007-01-05 | 2007-01-31 | 3 | 0d |  | GP [20.8%] | 30h |
| 50 | 1.10.3 | **Cierre** |  | 0.62d | 2007-01-25 | 2007-01-26 |  | 3.38d |  |  | 5h |
| 51 | 1.10.3.1 | Preparación Presentación Cierre de Proyecto |  | 0.12d | 2007-01-25 | 2007-01-25 | 38 | 3.38d | 0d | GP | 1h |
| 52 | 1.10.3.2 | Reunión Cierre de Proyecto |  | 0.5d | 2007-01-25 | 2007-01-26 | 51 | 3.38d |  | GP | 4h |
